# ROD TileCal Production Planning Valencia

Schedule from MS Project, 2003-10-15 to 2005-09-08.
Produccion de RODs en Valencia
IFIC-UV

## Calendars

- Standard: Mon-Fri 08:00-12:00, 13:00-17:00; Sat-Sun off.

## Schedule

| ID | WBS | Task | Duration | Start | Finish | Predecessors | Baseline start | Baseline finish | Baseline duration | Total slack | Free slack | Constraint |
| --- | --- | --- | --- | --- | --- | --- | --- | --- | --- | --- | --- | --- |
| 1 | 1 | **ROD TileCal Project** | 497d? | 2003-10-15 | 2005-09-08 |  | 2003-10-15 | 2005-09-08 | 497d? | 0d |  |  |
| 3 | 1.1 | **ROD Motherboard LiArg Prototype and Testing** | 152d? | 2004-02-02 | 2004-08-31 |  | 2004-02-02 | 2004-08-31 | 152d? | 62d |  |  |
| 4 | 1.1.1 | FDR LiArg | 1d? | 2004-02-02 | 2004-02-02 |  | 2004-02-02 | 2004-02-02 | 1d? | 136d | 0d | start no earlier than 2004-02-02 |
| 5 | 1.1.2 | LiArg BEC Tests | 150d? | 2004-02-03 | 2004-08-30 | 4 | 2004-02-03 | 2004-08-30 | 150d? | 136d | 0d |  |
| 6 | 1.1.3 | PRR LiArg | 1d? | 2004-06-25 | 2004-06-25 |  | 2004-06-25 | 2004-06-25 | 1d? | 314d |  | start no earlier than 2004-06-25 |
| 7 | 1.1.4 | Production Start Decision | 1d? | 2004-08-31 | 2004-08-31 | 5 | 2004-08-31 | 2004-08-31 | 1d? | 267d |  | start no earlier than 2004-08-31 |
| 9 | 1.2 | **PU-DSP Production** | 120d? | 2004-08-02 | 2005-01-14 |  | 2004-08-02 | 2005-01-14 | 120d? | 169d |  |  |
| 10 | 1.2.1 | Start Purchase of Components | 1d? | 2004-08-02 | 2004-08-02 |  | 2004-08-02 | 2004-08-02 | 1d? | 288d |  | start no earlier than 2004-08-02 |
| 11 | 1.2.2 | Production and Tests at LAPP Annecy | 98d? | 2004-09-01 | 2005-01-14 | 5 | 2004-09-01 | 2005-01-14 | 98d? | 169d |  | start no earlier than 2004-09-01 |
| 13 | 1.3 | **ROD Motherboard LiArg Production** | 248d? | 2004-06-28 | 2005-06-08 |  | 2004-06-28 | 2005-06-08 | 248d? | 66d |  |  |
| 14 | 1.3.1 | LiArg Procurement of Components | 75d? | 2004-06-28 | 2004-10-08 |  | 2004-06-28 | 2004-10-08 | 75d? | 239d |  | finish no earlier than 2004-10-08 |
| 15 | 1.3.2 | LiArg PCB Assembly and Cabling Preseries | 20d? | 2004-12-30 | 2005-01-26 |  | 2004-12-30 | 2005-01-26 | 20d? | 66d | 0d | finish no earlier than 2005-01-26 |
| 16 | 1.3.3 | LiArg Motherboard Preseries Tests (20 RODs) | 10d? | 2005-01-27 | 2005-02-09 | 15 | 2005-01-27 | 2005-02-09 | 10d? | 66d | 0d | finish no earlier than 2005-02-09 |
| 17 | 1.3.4 | LiArg PCB Assembly and Cabling Full Batch | 30d? | 2005-02-10 | 2005-03-23 | 16 | 2005-02-10 | 2005-03-23 | 30d? | 66d | 0d | finish no earlier than 2005-03-23 |
| 18 | 1.3.5 | LiArg Motherboard Installation Geneva | 50d? | 2005-03-24 | 2005-06-01 | 17 | 2005-03-24 | 2005-06-01 | 50d? | 71d |  | start no earlier than 2005-03-24 |
| 19 | 1.3.6 | LiArg Production Tests and QC | 55d? | 2005-03-24 | 2005-06-08 | 17 | 2005-03-24 | 2005-06-08 | 55d? | 66d | 16d | finish no earlier than 2005-06-08 |
| 21 | 1.4 | **ROD Motherboard TileCal Production** | 224d? | 2004-08-02 | 2005-06-09 |  | 2004-08-02 | 2005-06-09 | 224d? | 65d |  |  |
| 22 | 1.4.1 | Replacement Clocks and Components Preseries (4 RODs) | 21d? | 2005-02-10 | 2005-03-10 | 16 | 2005-02-10 | 2005-03-10 | 21d? | 130d |  | finish no earlier than 2005-03-10 |
| 23 | 1.4.2 | Replacement Clocks and Components Full Batch | 39d? | 2005-04-15 | 2005-06-08 | 19SS | 2005-04-15 | 2005-06-08 | 39d? | 66d |  | start no earlier than 2005-04-15 |
| 24 | 1.4.3 | TileCal Production Tests and QC | 39d? | 2005-04-18 | 2005-06-09 | 19SS, 26 | 2005-04-18 | 2005-06-09 | 39d? | 65d | 15d | finish no earlier than 2005-06-08 |
| 26 | 1.4.4 | **TileCal Production Test Bench Valencia** | 185d? | 2004-08-02 | 2005-04-15 |  | 2004-08-02 | 2005-04-15 | 185d? | 65d | 0d |  |
| 27 | 1.4.4.1 | FPGA Programming and Tunning | 185d? | 2004-08-02 | 2005-04-15 |  | 2004-08-02 | 2005-04-15 | 185d? | 65d |  | finish no earlier than 2005-04-15 |
| 28 | 1.4.4.2 | DSP Programming and Tunning | 185d? | 2004-08-02 | 2005-04-15 |  | 2004-08-02 | 2005-04-15 | 185d? | 65d |  | finish no earlier than 2005-04-15 |
| 29 | 1.4.4.3 | Standalone Software for Tests | 185d? | 2004-08-02 | 2005-04-15 |  | 2004-08-02 | 2005-04-15 | 185d? | 65d |  | finish no earlier than 2005-04-15 |

| ID | WBS | Task | Duration | Start | Finish | Predecessors | Baseline start | Baseline finish | Baseline duration | Total slack | Free slack | Constraint |
| --- | --- | --- | --- | --- | --- | --- | --- | --- | --- | --- | --- | --- |
| 31 | 1.5 | **PreROD Prototyping (4 Boards)** | 246d? | 2003-10-15 | 2004-09-22 |  | 2003-10-15 | 2004-09-22 | 246d? | 251d |  |  |
| 32 | 1.5.1 | Design, Schematics for Prototypes | 121d? | 2003-10-15 | 2004-03-31 |  | 2003-10-15 | 2004-03-31 | 121d? | 334d | 0d | finish no earlier than 2004-03-31 |
| 33 | 1.5.2 | Routing and Signal Integrity Prototypes | 42d? | 2004-04-01 | 2004-05-28 | 32 | 2004-04-01 | 2004-05-28 | 42d? | 334d |  | finish no earlier than 2004-05-28 |
| 34 | 1.5.3 | Ordering and Assembly of Components | 45d? | 2004-05-17 | 2004-07-16 |  | 2004-05-17 | 2004-07-16 | 45d? | 255d | 4d | finish no earlier than 2004-07-16 |
| 35 | 1.5.4 | Prototype Tests at TestBeam | 44d? | 2004-07-23 | 2004-09-22 | 34 | 2004-07-23 | 2004-09-22 | 44d? | 251d |  | finish no earlier than 2004-09-22 |
| 37 | 1.6 | **PreROD Production (?)** | 184d? | 2004-09-22 | 2005-06-06 |  | 2004-09-22 | 2005-06-06 | 184d? | 45d | 1d |  |
| 38 | 1.6.1 | Design, Schematics for Production | 87d? | 2004-09-22 | 2005-01-20 |  | 2004-09-22 | 2005-01-20 | 87d? | 106d | 0d | start no earlier than 2004-09-22 |
| 39 | 1.6.2 | Routing and Signal Integrity Production | 36d? | 2005-01-21 | 2005-03-11 | 38 | 2005-01-21 | 2005-03-11 | 36d? | 106d |  | finish no earlier than 2005-03-10 |
| 40 | 1.6.3 | Ordering, Assembly of Components Production | 44d? | 2005-03-15 | 2005-05-13 |  | 2005-03-15 | 2005-05-13 | 44d? | 45d | 0d | finish no earlier than 2005-05-13 |
| 41 | 1.6.4 | Production Tests and QC | 16d? | 2005-05-16 | 2005-06-06 | 40 | 2005-05-16 | 2005-06-06 | 16d? | 45d |  | finish no earlier than 2005-06-06 |
| 43 | 1.7 | **ROD Crate Production** | 178d? | 2004-09-01 | 2005-05-06 |  | 2004-09-01 | 2005-05-06 | 178d? | 78d | 0d |  |
| 44 | 1.7.1 | Order Crates | 1d? | 2004-11-15 | 2004-11-15 |  | 2004-11-15 | 2004-11-15 | 1d? | 89d | 11d | start no earlier than 2004-11-15 |
| 45 | 1.7.2 | CERN order | 45d? | 2004-12-01 | 2005-02-01 | 44 | 2004-12-01 | 2005-02-01 | 45d? | 78d | 0d | finish no earlier than 2005-02-01 |
| 46 | 1.7.3 | ROD Crate Production | 65d? | 2005-02-02 | 2005-05-03 | 45 | 2005-02-02 | 2005-05-03 | 65d? | 78d | 0d | finish no earlier than 2005-05-03 |
| 47 | 1.7.4 | ROD Crate Delivery | 1d? | 2005-05-04 | 2005-05-04 | 46 | 2005-05-04 | 2005-05-04 | 1d? | 78d | 0d |  |
| 48 | 1.7.5 | Cable Preparation | 10d? | 2005-02-02 | 2005-02-15 | 45 | 2005-02-02 | 2005-02-15 | 10d? | 136d |  | finish no earlier than 2005-02-15 |
| 49 | 1.7.6 | P3 Cards Ordering - LAL Orsay | 1d? | 2004-09-01 | 2004-09-01 | 5 | 2004-09-01 | 2004-09-01 | 1d? | 210d | 21d | start no earlier than 2004-09-01 |
| 50 | 1.7.7 | P3 Cards Assembly and Testing | 43d? | 2004-10-01 | 2004-11-30 | 49 | 2004-10-01 | 2004-11-30 | 43d? | 189d | 111d | finish no earlier than 2004-11-30 |
| 51 | 1.7.8 | P3 Card Installation | 2d? | 2005-05-05 | 2005-05-06 | 47, 50 | 2005-05-05 | 2005-05-06 | 2d? | 78d |  | finish no earlier than 2005-05-06 |
| 53 | 1.8 | **HOLAs Boards Production** | 143d? | 2004-09-15 | 2005-04-01 |  |  |  |  | 114d |  |  |
| 54 | 1.8.1 | HOLAs Boards Ordering - CERN | 1d? | 2004-09-15 | 2004-09-15 |  |  |  |  | 125d | 11d | start no earlier than 2004-09-15 |
| 55 | 1.8.2 | HOLAs Boards Assembly and Testing | 131d? | 2004-10-01 | 2005-04-01 | 54 |  |  |  | 114d |  | finish no earlier than 2005-04-01 |
| 57 | 1.9 | **TM Boards Production** | 148d? | 2004-09-15 | 2005-04-08 |  | 2004-09-15 | 2005-01-28 | 98d? | 64d | 20d |  |
| 58 | 1.9.1 | TM Boards Ordering - LAL Orsay | 1d? | 2004-09-15 | 2004-09-15 | 5 | 2004-09-15 | 2004-09-15 | 1d? | 75d | 11d | start no earlier than 2004-09-15 |
| 59 | 1.9.2 | TM Boards Assembly and Testing | 136d? | 2004-10-01 | 2005-04-08 | 58 | 2004-10-01 | 2005-01-28 | 86d? | 64d |  | finish no earlier than 2005-04-08 |

| ID | WBS | Task | Duration | Start | Finish | Predecessors | Baseline start | Baseline finish | Baseline duration | Total slack | Free slack | Constraint |
| --- | --- | --- | --- | --- | --- | --- | --- | --- | --- | --- | --- | --- |
| 61 | 1.10 | **TBM Boards Production** | 148d? | 2004-09-15 | 2005-04-08 |  | 2004-09-15 | 2004-11-30 | 55d? | 40d |  |  |
| 62 | 1.10.1 | TBM Ordering - LAL Orsay | 1d? | 2004-09-15 | 2004-09-15 | 5 | 2004-09-15 | 2004-09-15 | 1d? | 51d | 11d | start no earlier than 2004-09-15 |
| 63 | 1.10.2 | TBM Assembly and Testing | 136d? | 2004-10-01 | 2005-04-08 | 62 | 2004-10-08 | 2004-11-30 | 38d? | 40d |  | finish no earlier than 2005-04-08 |
| 65 | 1.11 | **ROD TileCal Installation and Commissioning USA15** | 266d? | 2004-09-02 | 2005-09-08 |  | 2004-09-02 | 2005-09-08 | 266d? | 0d |  |  |
| 66 | 1.11.1 | Installation of Racks | 21d? | 2004-09-02 | 2004-09-30 |  | 2004-09-02 | 2004-09-30 | 21d? | 245d |  | start no earlier than 2004-09-02 |
| 68 | 1.11.2 | **Reception and Preparation for Installation** | 45d? | 2005-05-09 | 2005-07-08 |  | 2005-05-09 | 2005-07-08 | 45d? | 44d |  |  |
| 69 | 1.11.2.1 | Reception and Tests of ROD Crates | 11d? | 2005-05-09 | 2005-05-23 | 43 | 2005-05-09 | 2005-05-23 | 11d? | 78d |  | finish no earlier than 2005-05-23 |
| 70 | 1.11.2.2 | Installation of ROD Motherboards | 45d? | 2005-05-09 | 2005-07-08 | 24SS | 2005-05-09 | 2005-07-08 | 45d? | 44d |  | finish no earlier than 2005-07-08 |
| 71 | 1.11.2.3 | Installation of TM Boards | 45d? | 2005-05-09 | 2005-07-08 | 57 | 2005-05-09 | 2005-07-08 | 45d? | 44d |  | start no earlier than 2005-05-09 |
| 72 | 1.11.2.4 | Installation of PreRODs | 23d? | 2005-06-08 | 2005-07-08 | 37 | 2005-06-08 | 2005-07-08 | 23d? | 44d |  | finish no earlier than 2005-07-08 |
| 74 | 1.11.3 | **Installation and Tests USA15** | 84d? | 2005-05-16 | 2005-09-08 |  | 2005-05-16 | 2005-09-08 | 84d? | 0d |  |  |
| 75 | 1.11.3.1 | Electrical and Network Cable Installation | 16d? | 2005-05-16 | 2005-06-06 |  | 2005-05-16 | 2005-06-06 | 16d? | 68d |  | finish no earlier than 2005-06-06 |
| 76 | 1.11.3.2 | PC Installation | 16d? | 2005-05-16 | 2005-06-06 |  | 2005-05-16 | 2005-06-06 | 16d? | 68d |  | finish no earlier than 2005-06-06 |
| 77 | 1.11.3.3 | ROD Crate Installation and Tests | 69d? | 2005-06-06 | 2005-09-08 |  | 2005-06-06 | 2005-09-08 | 69d? | 0d |  | finish no earlier than 2005-09-08 |
| 78 | 1.11.3.4 | SBC Configuration and VME Tests | 69d? | 2005-06-06 | 2005-09-08 |  | 2005-06-06 | 2005-09-08 | 69d? | 0d |  | finish no earlier than 2005-09-08 |
| 79 | 1.11.3.5 | ROD TTC Connection and Tests | 69d? | 2005-06-06 | 2005-09-08 |  | 2005-06-06 | 2005-09-08 | 69d? | 0d |  | finish no earlier than 2005-09-08 |
| 80 | 1.11.3.6 | Installation of TBM Boards | 69d? | 2005-06-06 | 2005-09-08 | 61 | 2005-06-06 | 2005-09-08 | 69d? | 0d |  | finish no earlier than 2005-09-08 |
| 81 | 1.11.3.7 | Installation and Connection to DCS | 69d? | 2005-06-06 | 2005-09-08 |  | 2005-06-06 | 2005-09-08 | 69d? | 0d |  | finish no earlier than 2005-09-08 |
| 82 | 1.11.3.8 | FEB and Optical Links Connections | 69d? | 2005-06-06 | 2005-09-08 |  | 2005-06-06 | 2005-09-08 | 69d? | 0d |  | finish no earlier than 2005-09-08 |
| 83 | 1.11.3.9 | Readout Optical Links Connections | 69d? | 2005-06-06 | 2005-09-08 |  | 2005-06-06 | 2005-09-08 | 69d? | 0d |  | finish no earlier than 2005-09-08 |
